# TP rekonstravimo darbų atlikimo grafikas

Schedule from MS Project, 2020-09-28 to 2022-10-18, costs in €.

## Calendars

- Standard: Mon-Fri 08:00-12:00, 13:00-17:00; Sat-Sun off. Exceptions (off unless hours are given): 2013-01-01 to 2030-01-01 (Naujieji metai, recurring), 2013-02-16 to 2030-02-16 (Valstybės atkurimo diena, recurring), 2013-03-11 to 2030-03-11 (Nepriklausomybes atkurimo diena, recurring), 2013-05-01 to 2030-05-01 (Tarptautine darbininku diena, recurring), 2013-06-24 to 2030-06-24 (Jonines (Rasos), recurring), 2013-07-06 to 2030-07-06 (Valstybes (Lietuvos karaliaus Mindaugo karunavimo) diena, recurring), 2013-08-15 to 2030-08-15 (Zoline, Sv. Mergeles Marijos dangun emimo svente, recurring), 2013-11-01 to 2030-11-01 (Visu sventuju diena, recurring), 2013-12-24 to 2030-12-24 (Sv. Kucios, recurring), 2013-12-25 to 2030-12-25 (Sv. Kaledos, recurring), 2013-12-26 to 2030-12-26 (Sv. Kaledos (antroji diena), recurring), 2019-06-20 to 2024-04-02 07:30-11:30, 12:15-16:30 (Darbo diena (I-IV) 07:30-16:30, recurring), 2019-06-21 to 2030-12-27 07:30-11:30, 12:15-15:15 (Darbo diena (V) 07:30-15:15, recurring), 2021-04-05 (Sv. Velykos (antroji diena)), 2022-04-18 (Sv. Velykos (antroji diena)).

## Resources

| Resource | Rate |
| --- | --- |
| Rangovas |  |
| Litgrid AB |  |
| Ekspertizės rangovas |  |
| Infostatyba |  |
| PV |  |
| ESO |  |
| _ITTAD ITTC TIG vyresnysis inžinierius | 17.8 |
| _ITTAD ITTC DPG PVS administratorius | 17.8 |
| _ITTAD ITTC VSG DVS administratorius | 17.8 |
| _ITTAD ITTC DPG duomenų tinklo administratorius (KR) | 17.8 |
| _ITTAD ITTC DPG duomenų tinklo administratorius (IP) | 17.8 |

## Schedule

| ID | WBS | Task | Type | Duration | Start | Finish | Predecessors | Baseline start | Baseline finish | Baseline duration | Total slack | Free slack | Resources | Work | Cost |
| --- | --- | --- | --- | --- | --- | --- | --- | --- | --- | --- | --- | --- | --- | --- | --- |
| 1 | 1 | Pasirašyta sutartis | milestone | 0d | 2020-09-28 | 2020-09-28 |  |  |  |  | 501d | 0d | Rangovas; Litgrid AB |  |  |
| 2 | 2 | Prašymas pateikti reikalingą dokumentaciją/informaciją projektavimo darbams |  | 5d | 2020-09-28 | 2020-10-05 | 1 |  |  |  | 5d | 0d | Rangovas | 40h |  |
| 3 | 3 | Pateikta reikalinga dokumentacija/informacija projektavimo darbams |  | 15d | 2020-10-05 | 2020-10-26 | 2 | 2019-12-18 | 2020-01-27 | 25d | 5d |  | Litgrid AB | 120h |  |
| 4 | 4 | **I ETAPAS. RANGOS DARBAI** |  | 470d | 2020-09-28 | 2022-08-05 |  | 2020-05-19 | 2022-01-18 | 424d | 0d |  |  | 16328h | 5,411.2 |
| 5 | 4.1 | **Pagrindinės įrangos parinkimas ir suderinimas** |  | 55d | 2020-09-28 | 2020-12-14 |  | 2020-05-19 | 2020-06-19 | 24d | 0d |  |  | 3520h |  |
| 6 | 4.1.1 | **Elektrotechnika [E]** |  | 55d | 2020-09-28 | 2020-12-14 |  | 2020-05-19 | 2020-06-19 | 24d | 0d |  |  | 440h |  |
| 7 | 4.1.1.1 | Parinkta elektrotechnikos dalies įranga ir pateikti 1 peržiūrai užpildyti techninių specifikacijų atitikimai LITGRID AB |  | 30d | 2020-09-28 | 2020-11-09 |  | 2020-05-19 | 2020-06-01 | 10d | 0d |  | Rangovas | 240h |  |
| 8 | 4.1.1.2 | Pateiktos pastabos užpildytoms techninėms specifikacijoms |  | 10d | 2020-11-09 | 2020-11-23 | 7 | 2020-06-02 | 2020-06-15 | 10d | 0d |  | Litgrid AB | 80h |  |
| 9 | 4.1.1.3 | Patikslinti techninių specifikacijų atitikimai ir pateikti 2 peržiūrai Litgrid AB |  | 5d | 2020-11-23 | 2020-11-30 | 8 | 2020-06-16 | 2020-06-17 | 2d | 0d |  | Rangovas | 40h |  |
| 10 | 4.1.1.4 | Patvirtinti techninių specifikacijų atitikimai - įranga suderinta |  | 10d | 2020-11-30 | 2020-12-14 | 9 | 2020-06-18 | 2020-06-19 | 2d | 0d |  | Litgrid AB | 80h |  |
| 11 | 4.1.2 | **Elektrotechnika (EL)** |  | 55d | 2020-09-28 | 2020-12-14 |  | 2020-05-19 | 2020-06-12 | 19d | 426d |  |  | 440h |  |
| 12 | 4.1.2.1 | Parinktos EL dalies medžiagos ir pateikti 1 peržiūrai užpildyti techninių specifikacijų atitikimai LITGRID AB |  | 30d | 2020-09-28 | 2020-11-09 |  | 2020-05-19 | 2020-05-25 | 5d | 426d | 0d | Rangovas | 240h |  |
| 13 | 4.1.2.2 | Pateiktos pastabos užpildytoms techninėms specifikacijoms |  | 10d | 2020-11-09 | 2020-11-23 | 12 | 2020-05-26 | 2020-06-08 | 10d | 426d | 0d | Litgrid AB | 80h |  |
| 14 | 4.1.2.3 | Patikslinti techninių specifikacijų atitikimai ir pateikti 2 peržiūrai Litgrid AB |  | 5d | 2020-11-23 | 2020-11-30 | 13 | 2020-06-09 | 2020-06-10 | 2d | 426d | 0d | Rangovas | 40h |  |
| 15 | 4.1.2.4 | Patvirtinti techninių specifikacijų atitikimai - įranga suderinta |  | 10d | 2020-11-30 | 2020-12-14 | 14 | 2020-06-11 | 2020-06-12 | 2d | 426d | 0d | Litgrid AB | 80h |  |
| 16 | 4.1.3 | **Procesų valdymas ir automatizacija (RAA)** |  | 55d | 2020-09-28 | 2020-12-14 |  | 2020-05-19 | 2020-06-19 | 24d | 47d |  |  | 440h |  |
| 17 | 4.1.3.1 | Parinkta RAA dalies įranga ir pateikti 1 peržiūrai užpildyti techninių specifikacijų atitikimai LITGRID AB |  | 30d | 2020-09-28 | 2020-11-09 |  | 2020-05-19 | 2020-06-01 | 10d | 47d | 0d | Rangovas | 240h |  |
| 18 | 4.1.3.2 | Pateiktos pastabos užpildytoms techninėms specifikacijoms |  | 10d | 2020-11-09 | 2020-11-23 | 17 | 2020-06-02 | 2020-06-15 | 10d | 47d | 0d | Litgrid AB | 80h |  |
| 19 | 4.1.3.3 | Patikslinti techninių specifikacijų atitikimai ir pateikti 2 peržiūrai Litgrid AB |  | 5d | 2020-11-23 | 2020-11-30 | 18 | 2020-06-16 | 2020-06-17 | 2d | 47d | 0d | Rangovas | 40h |  |
| 20 | 4.1.3.4 | Patvirtinti techninių specifikacijų atitikimai - įranga suderinta |  | 10d | 2020-11-30 | 2020-12-14 | 19 | 2020-06-18 | 2020-06-19 | 2d | 47d | 0d | Litgrid AB | 80h |  |
| 21 | 4.1.4 | **Procesų valdymas ir automatizacija (TSPĮ)** |  | 55d | 2020-09-28 | 2020-12-14 |  | 2020-05-19 | 2020-06-12 | 19d | 426d |  |  | 440h |  |
| 22 | 4.1.4.1 | Parinkta TSPĮ dalies įranga ir pateikti 1 peržiūrai užpildyti techninių specifikacijų atitikimai LITGRID AB |  | 30d | 2020-09-28 | 2020-11-09 |  | 2020-05-19 | 2020-05-25 | 5d | 426d | 0d | Rangovas | 240h |  |
| 23 | 4.1.4.2 | Pateiktos pastabos užpildytoms techninėms specifikacijoms |  | 10d | 2020-11-09 | 2020-11-23 | 22 | 2020-05-26 | 2020-06-08 | 10d | 426d | 0d | Litgrid AB | 80h |  |
| 24 | 4.1.4.3 | Patikslinti techninių specifikacijų atitikimai ir pateikti 2 peržiūrai Litgrid AB |  | 5d | 2020-11-23 | 2020-11-30 | 23 | 2020-06-09 | 2020-06-10 | 2d | 426d | 0d | Rangovas | 40h |  |
| 25 | 4.1.4.4 | Patvirtinti techninių specifikacijų atitikimai - įranga suderinta |  | 10d | 2020-11-30 | 2020-12-14 | 24 | 2020-06-11 | 2020-06-12 | 2d | 426d | 0d | Litgrid AB | 80h |  |

| ID | WBS | Task | Duration | Start | Finish | Predecessors | Baseline start | Baseline finish | Baseline duration | Total slack | Free slack | Resources | Work |
| --- | --- | --- | --- | --- | --- | --- | --- | --- | --- | --- | --- | --- | --- |
| 26 | 4.1.5 | **Procesų valdymas ir automatizacija (EEA)** | 55d | 2020-09-28 | 2020-12-14 |  | 2020-05-19 | 2020-06-12 | 19d | 426d |  |  | 440h |
| 27 | 4.1.5.1 | Parinkta EEA dalies įranga ir pateikti 1 peržiūrai užpildyti techninių specifikacijų atitikimai LITGRID AB | 30d | 2020-09-28 | 2020-11-09 |  | 2020-05-19 | 2020-05-25 | 5d | 426d | 0d | Rangovas | 240h |
| 28 | 4.1.5.2 | Pateiktos pastabos užpildytoms techninėms specifikacijoms | 10d | 2020-11-09 | 2020-11-23 | 27 | 2020-05-26 | 2020-06-08 | 10d | 426d | 0d | Litgrid AB | 80h |
| 29 | 4.1.5.3 | Patikslinti techninių specifikacijų atitikimai ir pateikti 2 peržiūrai Litgrid AB | 5d | 2020-11-23 | 2020-11-30 | 28 | 2020-06-09 | 2020-06-10 | 2d | 426d | 0d | Rangovas | 40h |
| 30 | 4.1.5.4 | Patvirtinti techninių specifikacijų atitikimai - įranga suderinta | 10d | 2020-11-30 | 2020-12-14 | 29 | 2020-06-11 | 2020-06-12 | 2d | 426d | 0d | Litgrid AB | 80h |
| 31 | 4.1.6 | **Telekomunikacijos (TK)** | 55d | 2020-09-28 | 2020-12-14 |  | 2020-05-19 | 2020-06-12 | 19d | 421d |  |  | 440h |
| 32 | 4.1.6.1 | Parinkta telekomunikacijos dalies įranga ir pateikti 1 peržiūrai užpildyti techninių specifikacijų atitikimai LITGRID AB | 30d | 2020-09-28 | 2020-11-09 |  | 2020-05-19 | 2020-05-25 | 5d | 421d | 0d | Rangovas | 240h |
| 33 | 4.1.6.2 | Pateiktos pastabos užpildytoms techninėms specifikacijoms | 10d | 2020-11-09 | 2020-11-23 | 32 | 2020-05-26 | 2020-06-08 | 10d | 421d | 0d | Litgrid AB | 80h |
| 34 | 4.1.6.3 | Patikslinti techninių specifikacijų atitikimai ir pateikti pakartotinei peržiūrai Litgrid AB | 5d | 2020-11-23 | 2020-11-30 | 33 | 2020-06-09 | 2020-06-10 | 2d | 421d | 0d | Rangovas | 40h |
| 35 | 4.1.6.4 | Patvirtinti techninių specifikacijų atitikimai - įranga suderinta | 10d | 2020-11-30 | 2020-12-14 | 34 | 2020-06-11 | 2020-06-12 | 2d | 421d | 0d | Litgrid AB | 80h |
| 36 | 4.1.7 | **Apsauginė-gaisrinė signalizacija (AGS)** | 55d | 2020-09-28 | 2020-12-14 |  | 2020-05-19 | 2020-06-12 | 19d | 426d |  |  | 440h |
| 37 | 4.1.7.1 | Parinkta AGS dalies įranga ir pateikti peržiūrai užpildyti techninių specifikacijų atitikimai LITGRID AB | 30d | 2020-09-28 | 2020-11-09 |  | 2020-05-19 | 2020-05-25 | 5d | 426d | 0d | Rangovas | 240h |
| 38 | 4.1.7.2 | Pateiktos pastabos užpildytoms techninėms specifikacijoms | 10d | 2020-11-09 | 2020-11-23 | 37 | 2020-05-26 | 2020-06-08 | 10d | 426d | 0d | Litgrid AB | 80h |
| 39 | 4.1.7.3 | Patikslinti techninių specifikacijų atitikimai ir pateikti pakartotinei peržiūrai Litgrid AB | 5d | 2020-11-23 | 2020-11-30 | 38 | 2020-06-09 | 2020-06-10 | 2d | 426d | 0d | Rangovas | 40h |
| 40 | 4.1.7.4 | Patvirtinti techninių specifikacijų atitikimai - įranga suderinta | 10d | 2020-11-30 | 2020-12-14 | 39 | 2020-06-11 | 2020-06-12 | 2d | 426d | 0d | Litgrid AB | 80h |
| 41 | 4.1.8 | **Statybinės konstrukcijos (SK)** | 55d | 2020-09-28 | 2020-12-14 |  | 2020-05-19 | 2020-06-12 | 19d | 5d |  |  | 440h |
| 42 | 4.1.8.1 | Parinktos SK dalies medžiagos ir pateikti peržiūrai užpildyti techninių specifikacijų atitikimai LITGRID AB | 30d | 2020-09-28 | 2020-11-09 |  | 2020-05-19 | 2020-05-25 | 5d | 5d | 0d | Rangovas | 240h |
| 43 | 4.1.8.2 | Pateiktos pastabos užpildytoms techninėms specifikacijoms | 10d | 2020-11-09 | 2020-11-23 | 42 | 2020-05-26 | 2020-06-08 | 10d | 5d | 0d | Litgrid AB | 80h |
| 44 | 4.1.8.3 | Patikslinti techninių specifikacijų atitikimai ir pateikti pakartotinei peržiūrai Litgrid AB | 5d | 2020-11-23 | 2020-11-30 | 43 | 2020-06-09 | 2020-06-10 | 2d | 5d | 0d | Rangovas | 40h |
| 45 | 4.1.8.4 | Patvirtinti techninių specifikacijų atitikimai - įranga suderinta | 10d | 2020-11-30 | 2020-12-14 | 44 | 2020-06-11 | 2020-06-12 | 2d | 5d | 0d | Litgrid AB | 80h |
| 46 | 4.2 | **RAA nuostatų pateikimas I statybos etapui** | 68d | 2020-12-14 | 2021-03-24 |  | 2020-06-22 | 2020-09-21 | 64d | 47d |  |  | 544h |
| 47 | 4.2.1 | OL RAA nuostatų I rekonstrukcijos etapui skaičiavimas | 21d | 2020-12-14 | 2021-01-14 | 20 |  |  |  | 47d | 0d | Litgrid AB | 168h |
| 48 | 4.2.2 | OL RAA nuostatų I rekonstrukcijos etapo užduočių rengimas | 13d | 2021-01-14 | 2021-02-02 | 47 |  |  |  | 47d | 0d | Litgrid AB | 104h |
| 49 | 4.2.3 | Šynų; prijunginių jungtuvų RAA nuostatų I rekonstrukcijos etapui skaičiavimas ir užduočių rengimas | 13d | 2021-02-02 | 2021-02-22 | 48 |  |  |  | 47d | 0d | Litgrid AB | 104h |
| 50 | 4.2.4 | Galios transformatorių įvadų TS- 100 RAA nuostatų skaičiavimas 15 dienų | 15d | 2021-02-22 | 2021-03-16 | 49 |  |  |  | 47d | 0d | Litgrid AB | 120h |
| 51 | 4.2.5 | I rekonstrukcijos etapo užduočių rengimas | 5d | 2021-03-16 | 2021-03-23 | 50 |  |  |  | 47d | 0d | Litgrid AB | 40h |
| 52 | 4.2.6 | Užduočių pateikimas | 1d | 2021-03-23 | 2021-03-24 | 51 |  |  |  | 47d | 0d | Litgrid AB | 8h |

| ID | WBS | Task | Duration | Start | Finish | Predecessors | Baseline start | Baseline finish | Baseline duration | Total slack | Free slack | Resources | Work |
| --- | --- | --- | --- | --- | --- | --- | --- | --- | --- | --- | --- | --- | --- |
| 53 | 4.3 | **I darbų etapo signalų sąrašai** | 50d | 2021-03-24 | 2021-06-03 |  |  |  |  | 47d |  |  | 640h |
| 54 | 4.3.1 | Suprojektuoti ir pateikti 1 peržiūrai ir derinimui XX TP; bei kitų su XX TP rekonstrukcija susijusių objektų (pagal poreikį); signalų sąrašai Litgrid AB ir ESO | 10d | 2021-03-24 | 2021-04-08 | 52 | 2020-10-21 | 2020-11-10 | 15d | 47d | 0d | Rangovas | 80h |
| 55 | 4.3.2 | Pateiktos pastabos po 1 peržiūros | 15d | 2021-04-08 | 2021-04-29 | 54 | 2020-11-11 | 2020-12-01 | 15d | 47d | 0d | Litgrid AB; ESO | 240h |
| 56 | 4.3.3 | Pakoreguoti pagal pastabas ir pateikti 2 peržiūrai ir derinimui signalų sąrašai Litgrid AB ir ESO | 5d | 2021-04-29 | 2021-05-06 | 55 | 2020-12-02 | 2020-12-08 | 5d | 47d | 0d | Rangovas | 40h |
| 57 | 4.3.4 | Pateiktos pastabos po 2 peržiūros | 10d | 2021-05-06 | 2021-05-20 | 56 | 2020-12-09 | 2020-12-22 | 10d | 47d | 0d | Litgrid AB; ESO | 160h |
| 58 | 4.3.5 | Pakoreguoti pagal pastabas ir pateikti III peržiūrai ir derinimui signalų sąrašai Litgrid AB ir ESO | 5d | 2021-05-20 | 2021-05-27 | 57 | 2020-12-23 | 2020-12-31 | 5d | 47d | 0d | Rangovas | 40h |
| 59 | 4.3.6 | I darbų etapo signalų sąrašai suderinti | 5d | 2021-05-27 | 2021-06-03 | 58 | 2021-01-04 | 2021-01-08 | 5d | 47d | 0d | Litgrid AB; ESO | 80h |
| 60 | 4.4 | **Darbo projektas** | 90d | 2020-12-14 | 2021-04-26 |  | 2020-08-19 | 2021-01-28 | 114d | 0d |  |  | 3768h |
| 61 | 4.4.1 | **Sklypo planas (SP)** | 40d | 2021-02-10 | 2021-04-12 |  | 2020-11-12 | 2021-01-04 | 35d | 0d |  |  | 320h |
| 62 | 4.4.1.1 | Suprojektuota ir pateikta 1 peržiūrai | 10d | 2021-02-10 | 2021-02-25 | 71, 77 | 2020-11-12 | 2020-11-25 | 10d | 0d |  | Rangovas | 80h |
| 63 | 4.4.1.2 | Pateiktos pastabos po 1 peržiūros | 15d | 2021-02-25 | 2021-03-19 | 62 | 2020-11-26 | 2020-12-16 | 15d | 0d |  | Litgrid AB | 120h |
| 64 | 4.4.1.3 | Pakoreguota pagal pastabas ir pateikta 2 peržiūrai | 5d | 2021-03-19 | 2021-03-26 | 63 | 2020-12-17 | 2020-12-23 | 5d | 0d |  | Rangovas | 40h |
| 65 | 4.4.1.4 | Darbo projekto dalis suderinta | 5d | 2021-03-26 | 2021-04-02 | 64 | 2020-12-28 | 2021-01-04 | 5d | 0d |  | Litgrid AB | 40h |
| 66 | 4.4.1.5 | Darbo projekto pateikimas Statytojui su žyma "Pritariu statyti" | 5d | 2021-04-02 | 2021-04-12 | 65 |  |  |  | 386d |  | Rangovas | 40h |
| 67 | 4.4.2 | **Elektrotechnika [E]** | 45d | 2020-12-14 | 2021-02-18 |  | 2020-08-19 | 2020-10-13 | 40d | 0d |  |  | 360h |
| 68 | 4.4.2.1 | Suprojektuota ir pateikta 1 peržiūrai | 15d | 2020-12-14 | 2021-01-06 | 10 | 2020-08-19 | 2020-09-08 | 15d | 0d |  | Rangovas | 120h |
| 69 | 4.4.2.2 | Pateiktos pastabos po 1 peržiūros | 15d | 2021-01-06 | 2021-01-27 | 68 | 2020-09-09 | 2020-09-29 | 15d | 0d |  | Litgrid AB | 120h |
| 70 | 4.4.2.3 | Pakoreguota pagal pastabas ir pateikta 2 peržiūrai | 5d | 2021-01-27 | 2021-02-03 | 69 | 2020-09-30 | 2020-10-06 | 5d | 0d |  | Rangovas | 40h |
| 71 | 4.4.2.4 | Darbo projekto dalis suderinta | 5d | 2021-02-03 | 2021-02-10 | 70 | 2020-10-07 | 2020-10-13 | 5d | 0d |  | Litgrid AB | 40h |
| 72 | 4.4.2.5 | Darbo projekto pateikimas Statytojui su žyma "Pritariu statyti" | 5d | 2021-02-10 | 2021-02-18 | 71 |  |  |  | 421d |  | Rangovas | 40h |
| 73 | 4.4.3 | **Konstrukcijos (SK)** | 66d | 2020-12-14 | 2021-03-22 |  | 2020-08-19 | 2020-11-11 | 61d | 5d |  |  | 648h |
| 74 | 4.4.3.1 | Suprojektuota ir pateikta 1 peržiūrai | 10d | 2020-12-14 | 2020-12-29 | 45 | 2020-08-19 | 2020-09-01 | 10d | 5d | 0d | Rangovas | 80h |
| 75 | 4.4.3.2 | Pateiktos pastabos po 1 peržiūros | 15d | 2020-12-29 | 2021-01-20 | 74 | 2020-09-02 | 2020-09-22 | 15d | 5d | 0d | Litgrid AB | 120h |
| 76 | 4.4.3.3 | Pakoreguota pagal pastabas ir pateikta 2 peržiūrai | 5d | 2021-01-20 | 2021-01-27 | 75 | 2020-09-23 | 2020-09-29 | 5d | 5d | 0d | Rangovas | 40h |
| 77 | 4.4.3.4 | Darbo projekto dalis suderinta | 5d | 2021-01-27 | 2021-02-03 | 76 | 2020-09-30 | 2020-10-06 | 5d | 5d | 0d | Litgrid AB | 40h |
| 78 | 4.4.3.5 | Pateikta SK darbo projekto dalis ekspertizei | 1d | 2021-02-03 | 2021-02-04 | 77 | 2020-10-07 | 2020-10-07 | 1d | 14d | 0d | Litgrid AB | 8h |
| 79 | 4.4.3.6 | Pateiktos ekspertizės pastabos | 15d | 2021-02-04 | 2021-02-26 | 78 | 2020-10-08 | 2020-10-28 | 15d | 14d | 0d | Ekspertizės rangovas; Litgrid AB | 240h |
| 80 | 4.4.3.7 | Pateikta pakoreguota SK darbo projekto dalis ekspertizei | 5d | 2021-02-26 | 2021-03-05 | 79 | 2020-10-29 | 2020-11-04 | 5d | 14d | 0d | Rangovas | 40h |
| 81 | 4.4.3.8 | Gautos teigiamos ekspertizės išvados | 5d | 2021-03-05 | 2021-03-15 | 80 | 2020-11-05 | 2020-11-11 | 5d | 14d | 0d | Ekspertizės rangovas | 40h |
| 82 | 4.4.3.9 | Darbo projekto pateikimas Statytojui su žyma "Pritariu statyti" | 5d | 2021-03-15 | 2021-03-22 | 81 |  |  |  | 400d |  | Rangovas | 40h |

| ID | WBS | Task | Duration | Start | Finish | Predecessors | Baseline start | Baseline finish | Baseline duration | Total slack | Free slack | Resources | Work |
| --- | --- | --- | --- | --- | --- | --- | --- | --- | --- | --- | --- | --- | --- |
| 83 | 4.4.4 | **Elektrotechnika (EL)** | 40d | 2020-12-14 | 2021-02-10 |  | 2020-08-19 | 2020-10-06 | 35d | 426d |  |  | 320h |
| 84 | 4.4.4.1 | Suprojektuota ir pateikta 1 peržiūrai | 10d | 2020-12-14 | 2020-12-29 | 15 | 2020-08-19 | 2020-09-01 | 10d | 426d | 0d | Rangovas | 80h |
| 85 | 4.4.4.2 | Pateiktos pastabos po 1 peržiūros | 15d | 2020-12-29 | 2021-01-20 | 84 | 2020-09-02 | 2020-09-22 | 15d | 426d | 0d | Litgrid AB | 120h |
| 86 | 4.4.4.3 | Pakoreguota pagal pastabas ir pateikta 2 peržiūrai | 5d | 2021-01-20 | 2021-01-27 | 85 | 2020-09-23 | 2020-09-29 | 5d | 426d | 0d | Rangovas | 40h |
| 87 | 4.4.4.4 | Darbo projekto dalis suderinta | 5d | 2021-01-27 | 2021-02-03 | 86 | 2020-09-30 | 2020-10-06 | 5d | 426d | 0d | Litgrid AB | 40h |
| 88 | 4.4.4.5 | Darbo projekto pateikimas Statytojui su žyma "Pritariu statyti" | 5d | 2021-02-03 | 2021-02-10 | 87 |  |  |  | 426d |  | Rangovas | 40h |
| 89 | 4.4.5 | **Procesų valdymas ir automatizacija (RAA)** | 50d | 2020-12-14 | 2021-02-25 |  | 2020-08-19 | 2020-10-20 | 45d | 410d |  |  | 400h |
| 90 | 4.4.5.1 | Suprojektuota ir pateikta 1 peržiūrai | 20d | 2020-12-14 | 2021-01-13 | 20 | 2020-08-19 | 2020-09-15 | 20d | 410d | 0d | Rangovas | 160h |
| 91 | 4.4.5.2 | Pateiktos pastabos po 1 peržiūros | 15d | 2021-01-13 | 2021-02-03 | 90 | 2020-09-16 | 2020-10-06 | 15d | 410d | 0d | Litgrid AB | 120h |
| 92 | 4.4.5.3 | Pakoreguota pagal pastabas ir pateikta 2 peržiūrai | 5d | 2021-02-03 | 2021-02-10 | 91 | 2020-10-07 | 2020-10-13 | 5d | 410d | 0d | Rangovas | 40h |
| 93 | 4.4.5.4 | Darbo projekto dalis suderinta | 5d | 2021-02-10 | 2021-02-18 | 92 | 2020-10-14 | 2020-10-20 | 5d | 410d | 0d | Litgrid AB | 40h |
| 94 | 4.4.5.5 | Darbo projekto pateikimas Statytojui su žyma "Pritariu statyti" | 5d | 2021-02-18 | 2021-02-25 | 93 |  |  |  | 416d |  | Rangovas | 40h |
| 95 | 4.4.6 | **Procesų valdymas ir automatizacija (TSPĮ)** | 40d | 2020-12-14 | 2021-02-10 |  | 2020-08-19 | 2020-10-06 | 35d | 426d |  |  | 320h |
| 96 | 4.4.6.1 | Suprojektuota ir pateikta 1 peržiūrai | 10d | 2020-12-14 | 2020-12-29 | 25 | 2020-08-19 | 2020-09-01 | 10d | 426d | 0d | Rangovas | 80h |
| 97 | 4.4.6.2 | Pateiktos pastabos po 1 peržiūros | 15d | 2020-12-29 | 2021-01-20 | 96 | 2020-09-02 | 2020-09-22 | 15d | 426d | 0d | Litgrid AB | 120h |
| 98 | 4.4.6.3 | Pakoreguota pagal pastabas ir pateikta 2 peržiūrai | 5d | 2021-01-20 | 2021-01-27 | 97 | 2020-09-23 | 2020-09-29 | 5d | 426d | 0d | Rangovas | 40h |
| 99 | 4.4.6.4 | Darbo projekto dalis suderinta | 5d | 2021-01-27 | 2021-02-03 | 98 | 2020-09-30 | 2020-10-06 | 5d | 426d | 0d | Litgrid AB | 40h |
| 100 | 4.4.6.5 | Darbo projekto pateikimas Statytojui su žyma "Pritariu statyti" | 5d | 2021-02-03 | 2021-02-10 | 99 |  |  |  | 426d |  | Rangovas | 40h |
| 101 | 4.4.7 | **Procesų valdymas ir automatizacija (EEA)** | 40d | 2020-12-14 | 2021-02-10 |  | 2020-08-19 | 2020-10-06 | 35d | 426d |  |  | 320h |
| 102 | 4.4.7.1 | Suprojektuota ir pateikta 1 peržiūrai | 10d | 2020-12-14 | 2020-12-29 | 30 | 2020-08-19 | 2020-09-01 | 10d | 426d | 0d | Rangovas | 80h |
| 103 | 4.4.7.2 | Pateiktos pastabos po 1 peržiūros | 15d | 2020-12-29 | 2021-01-20 | 102 | 2020-09-02 | 2020-09-22 | 15d | 426d | 0d | Litgrid AB | 120h |
| 104 | 4.4.7.3 | Pakoreguota pagal pastabas ir pateikta 2 peržiūrai | 5d | 2021-01-20 | 2021-01-27 | 103 | 2020-09-23 | 2020-09-29 | 5d | 426d | 0d | Rangovas | 40h |
| 105 | 4.4.7.4 | Darbo projekto dalis suderinta | 5d | 2021-01-27 | 2021-02-03 | 104 | 2020-09-30 | 2020-10-06 | 5d | 426d | 0d | Litgrid AB | 40h |
| 106 | 4.4.7.5 | Darbo projekto pateikimas Statytojui su žyma "Pritariu statyti" | 5d | 2021-02-03 | 2021-02-10 | 105 |  |  |  | 426d |  | Rangovas | 40h |

| ID | WBS | Task | Type | Duration | Start | Finish | Predecessors | Baseline start | Baseline finish | Baseline duration | Total slack | Free slack | Resources | Work |
| --- | --- | --- | --- | --- | --- | --- | --- | --- | --- | --- | --- | --- | --- | --- |
| 107 | 4.4.8 | **Telekomunikacijos (TK)** |  | 45d | 2020-12-14 | 2021-02-18 |  | 2020-08-19 | 2020-10-13 | 40d | 421d |  |  | 360h |
| 108 | 4.4.8.1 | Suprojektuota ir pateikta 1 peržiūrai |  | 15d | 2020-12-14 | 2021-01-06 | 35 | 2020-08-19 | 2020-09-08 | 15d | 421d | 0d | Rangovas | 120h |
| 109 | 4.4.8.2 | Pateiktos pastabos po 1 peržiūros |  | 15d | 2021-01-06 | 2021-01-27 | 108 | 2020-09-09 | 2020-09-29 | 15d | 421d | 0d | Litgrid AB | 120h |
| 110 | 4.4.8.3 | Pakoreguota pagal pastabas ir pateikta 2 peržiūrai |  | 5d | 2021-01-27 | 2021-02-03 | 109 | 2020-09-30 | 2020-10-06 | 5d | 421d | 0d | Rangovas | 40h |
| 111 | 4.4.8.4 | Darbo projekto dalis suderinta |  | 5d | 2021-02-03 | 2021-02-10 | 110 | 2020-10-07 | 2020-10-13 | 5d | 421d | 0d | Litgrid AB | 40h |
| 112 | 4.4.8.5 | Darbo projekto pateikimas Statytojui su žyma "Pritariu statyti" |  | 5d | 2021-02-10 | 2021-02-18 | 111 |  |  |  | 421d |  | Rangovas | 40h |
| 113 | 4.4.9 | **Apsauginės-gaisrinės signalizacija (AGS)** |  | 40d | 2020-12-14 | 2021-02-10 |  | 2020-08-19 | 2020-10-06 | 35d | 426d |  |  | 320h |
| 114 | 4.4.9.1 | Suprojektuota ir pateikta 1 peržiūrai |  | 10d | 2020-12-14 | 2020-12-29 | 40 | 2020-08-19 | 2020-09-01 | 10d | 426d | 0d | Rangovas | 80h |
| 115 | 4.4.9.2 | Pateiktos pastabos po 1 peržiūros |  | 15d | 2020-12-29 | 2021-01-20 | 114 | 2020-09-02 | 2020-09-22 | 15d | 426d | 0d | Litgrid AB | 120h |
| 116 | 4.4.9.3 | Pakoreguota pagal pastabas ir pateikta 2 peržiūrai |  | 5d | 2021-01-20 | 2021-01-27 | 115 | 2020-09-23 | 2020-09-29 | 5d | 426d | 0d | Rangovas | 40h |
| 117 | 4.4.9.4 | Darbo projekto dalis suderinta |  | 5d | 2021-01-27 | 2021-02-03 | 116 | 2020-09-30 | 2020-10-06 | 5d | 426d | 0d | Litgrid AB | 40h |
| 118 | 4.4.9.5 | Darbo projekto pateikimas Statytojui su žyma "Pritariu statyti" |  | 5d | 2021-02-03 | 2021-02-10 | 117 |  |  |  | 426d |  | Rangovas | 40h |
| 119 | 4.4.10 | **Vandentiekio ir nuotekų dalis (VN)** |  | 40d | 2021-02-25 | 2021-04-26 |  | 2020-11-26 | 2021-01-18 | 35d | 376d |  |  | 320h |
| 120 | 4.4.10.1 | Suprojektuota ir pateikta 1 peržiūrai |  | 10d | 2021-02-25 | 2021-03-12 | 62 | 2020-11-26 | 2020-12-09 | 10d | 376d | 0d | Rangovas | 80h |
| 121 | 4.4.10.2 | Pateiktos pastabos po 1 peržiūros |  | 15d | 2021-03-12 | 2021-04-02 | 120 | 2020-12-10 | 2021-01-04 | 15d | 376d | 0d | Litgrid AB | 120h |
| 122 | 4.4.10.3 | Pakoreguota pagal pastabas ir pateikta 2 peržiūrai |  | 5d | 2021-04-02 | 2021-04-12 | 121 | 2021-01-05 | 2021-01-11 | 5d | 376d | 0d | Rangovas | 40h |
| 123 | 4.4.10.4 | Darbo projekto dalis suderinta |  | 5d | 2021-04-12 | 2021-04-19 | 122 | 2021-01-12 | 2021-01-18 | 5d | 376d | 0d | Litgrid AB | 40h |
| 124 | 4.4.10.5 | Darbo projekto pateikimas Statytojui su žyma "Pritariu statyti" |  | 5d | 2021-04-19 | 2021-04-26 | 123 |  |  |  | 376d |  | Rangovas | 40h |
| 125 | 4.4.11 | Rangovas pateikia prašymą dėl IP dresų suteikimo |  | 1d | 2021-02-18 | 2021-02-19 | 93 |  |  |  | 410d | 0d |  |  |
| 126 | 4.4.12 | IP adresų suteikimas TSPĮ;MDV;GPS;RAA įrenginiams |  | 10d | 2021-02-19 | 2021-03-05 | 125 |  |  |  | 410d |  | Litgrid AB | 80h |
| 127 | 4.5 | **Darbų-atjungimų grafikas** |  | 54d | 2020-11-23 | 2021-02-09 |  |  |  |  | 427d |  |  | 752h |
| 128 | 4.5.1 | Pateiktas darbų-atjungimų grafikas 1 periūrai | milestone | 0d | 2020-11-23 | 2020-11-23 | 136SS-90d |  |  |  | 427d | 0d | Rangovas |  |
| 129 | 4.5.2 | Pateiktos pastabos po 1 peržiūros |  | 15d | 2020-11-23 | 2020-12-14 | 128 |  |  |  | 427d | 0d | Litgrid AB; ESO | 240h |
| 130 | 4.5.3 | Pateiktas darbų-atjungimų grafikas 2 peržiūrai |  | 7d | 2020-12-14 | 2020-12-22 | 129 |  |  |  | 427d | 0d | Rangovas | 56h |
| 131 | 4.5.4 | Pateiktos pastabos po 2 peržiūros |  | 15d | 2020-12-23 | 2021-01-15 | 130 |  |  |  | 427d | 0d | Litgrid AB; ESO | 240h |
| 132 | 4.5.5 | Pateiktas darbų-atjungimų grafikas 3 peržiūrai |  | 7d | 2021-01-15 | 2021-01-26 | 131 |  |  |  | 427d | 0d | Rangovas | 56h |
| 133 | 4.5.6 | Suderintas darbų-atjungimų grafikas |  | 10d | 2021-01-26 | 2021-02-09 | 132, 136SS-60d |  |  |  | 427d |  | Litgrid AB; ESO | 160h |
| 134 | 4.6 | Statybos aikštelės perdavimas rangovui |  | 3d | 2021-04-02 | 2021-04-08 | 81, 65 |  |  |  | 388d |  | Litgrid AB | 24h |

Notes:
- 125: Reikia RAA nuostatų ir signalų sąrašo suderinto

| ID | WBS | Task | Duration | Start | Finish | Predecessors | Total slack | Free slack | Resources | Work | Cost |
| --- | --- | --- | --- | --- | --- | --- | --- | --- | --- | --- | --- |
| 135 | 4.7 | **II ETAPAS. I etapo statybos darbai** | 178d | 2021-04-02 | 2021-12-14 |  | 0d |  | Rangovas | 2816h | 427.2 |
| 136 | 4.7.1 | Rangovas detalizuoja darbus | 90d | 2021-04-02 | 2021-08-11 | 81, 65 | 0d |  |  |  |  |
| 137 | 4.7.2 | Principinės objekto schemos pateikimas (OL permaitinimai ir kt. Pagal suderintą atjungimų grafiką) | 3d | 2021-04-02 | 2021-04-08 | 136SS | 385d | 0d | Rangovas | 24h |  |
| 138 | 4.7.3 | TSM modelio keitimas (dėl I etapo išmontuojamos dalies) | 3d | 2021-04-08 | 2021-04-13 | 137 | 385d |  | _ITTAD ITTC VSG DVS administratorius | 24h | 427.2 |
| 139 | 4.7.4 | RAA derinimo darbai | 15d | 2021-08-11 | 2021-09-01 | 136, 59 | 0d |  | Rangovas | 120h |  |
| 140 | 4.7.5 | TSPĮ įrangos derinimo darbai | 15d | 2021-09-01 | 2021-09-22 | 139 | 0d |  | Rangovas | 120h |  |
| 141 | 4.7.6 | Teleinformacijos testavimai tarp RAA terminalų (valdiklių) ir TSPĮ | 1d | 2021-09-22 | 2021-09-23 | 140 | 264d | 0d | Rangovas; Litgrid AB | 16h |  |
| 142 | 4.7.7 | Ryšių; įrangos derinimo darbai | 15d | 2021-09-01 | 2021-09-22 | 140SS | 0d |  | Rangovas | 120h |  |
| 143 | 4.7.8 | Užsakymo pateikimas duomenų telekomunikacijų įrangos prijungimui į Litgrid AB TDPT | 1d | 2021-09-22 | 2021-09-23 | 142 | 0d |  | Rangovas | 8h |  |
| 144 | 4.7.9 | Litgrid AB TDPT įrangos parengimas/konfigūravimas naujos telekomunikacijų įrangos (IP; SDH; RRL; Šviesolaidis) prijungimui | 4d | 2021-09-23 | 2021-09-29 | 143 | 0d |  | Litgrid AB | 32h |  |
| 145 | 4.7.10 | RAA OĮB rengimas/tvirtinimas | 10d | 2021-09-22 | 2021-10-06 | 140, 142 | 251d | 0d | Rangovas; Litgrid AB | 160h |  |
| 146 | 4.7.11 | Tipinių perjungimo lapelių ruošimas/tvirtinimas | 10d | 2021-10-06 | 2021-10-20 | 145 | 251d |  | Rangovas | 80h |  |
| 147 | 4.7.12 | **DVS (SCADA/EMS) parengiamieji darbai kompleksiniams bandymams (DVS realaus laiko displėjų parengimas; DVS vystymo sistemos konfigūravimas)** | 11d | 2021-06-03 | 2021-06-18 |  | 81d |  |  | 88h |  |
| 148 | 4.7.12.1 | DVS vystymo sistemos konfigūravimas pagal paskutinį suderintą signalų sąrašą | 3d | 2021-06-03 | 2021-06-08 | 59 | 81d | 0d | Litgrid AB | 24h |  |
| 149 | 4.7.12.2 | Principinės objekto schemos pateikimas; linijų; transformatorių parametrų pateikimas | 3d | 2021-06-08 | 2021-06-11 | 148 | 81d | 0d | Rangovas | 24h |  |
| 150 | 4.7.12.3 | DVS realaus laiko displėjų parengimas | 5d | 2021-06-11 | 2021-06-18 | 148, 149 | 81d |  | Litgrid AB | 40h |  |
| 151 | 4.7.13 | TSPĮ konfigūracijos pateikimas | 1d | 2021-09-23 | 2021-09-24 | 141 | 264d | 0d | Rangovas | 8h |  |
| 152 | 4.7.14 | TSPĮ konfigūracijos derinimas su užsakovu | 5d | 2021-09-27 | 2021-10-01 | 151 | 264d |  | Litgrid AB | 40h |  |
| 153 | 4.7.15 | Įrenginių testavimas bandymai objekte ir/ar tarp skirtingų objektų (pasiruošimas kompleksiniams bandymas) | 10d | 2021-09-29 | 2021-10-13 | 144 | 0d |  | Rangovas | 80h |  |
| 154 | 4.7.16 | Įrenginių kompleksiniai bandymai su PSO SCADA | 7d | 2021-10-13 | 2021-10-22 | 150, 153 | 0d |  | Rangovas; Litgrid AB | 112h |  |
| 155 | 4.7.17 | **DVS (SCADA/EMS) baigiamieji etapo darbai** | 11d | 2021-10-25 | 2021-11-09 |  | 0d |  |  | 120h |  |
| 156 | 4.7.17.1 | Konfigūracijos perkėlimas iš vystymo DVS į darbinę DVS | 1d | 2021-10-25 | 2021-10-25 | 154 | 0d |  | Litgrid AB | 8h |  |
| 157 | 4.7.17.2 | Skaičiuojamųjų matavimų sukonfigūravimas DVS | 3d | 2021-10-25 | 2021-10-28 | 156 | 0d |  | Litgrid AB | 24h |  |
| 158 | 4.7.17.3 | DVS realaus laiko displėjų parengimo užbaigimas | 7d | 2021-10-28 | 2021-11-09 | 157 | 238d |  | Litgrid AB | 56h |  |
| 159 | 4.7.17.4 | DVS teisių koregavimas (jeigu įtraukiamas naujas objektas) | 1d | 2021-10-28 | 2021-10-29 | 157 | 0d |  | Litgrid AB | 8h |  |
| 160 | 4.7.17.5 | TSM modelio keitimas (dėl I etapo) | 2d | 2021-11-02 | 2021-11-03 | 159, 149 | 0d |  | Litgrid AB | 16h |  |
| 161 | 4.7.17.6 | TDPT naujos įrangos įvedimas į monitoringo ir valdymo sistemas | 1d | 2021-11-03 | 2021-11-04 | 160 | 0d |  | Litgrid AB | 8h |  |

| ID | WBS | Task | Type | Duration | Start | Finish | Predecessors | Total slack | Free slack | Resources | Work | Cost |
| --- | --- | --- | --- | --- | --- | --- | --- | --- | --- | --- | --- | --- |
| 162 | 4.7.18 | **Techninio įvertinimo komisija (I etapo)** |  | 28d | 2021-11-04 | 2021-12-14 |  | 0d |  |  | 240h |  |
| 163 | 4.7.18.1 | Techninės dokumentacijos pateikimas Užsakovui |  | 5d | 2021-11-04 | 2021-11-11 | 161 | 0d |  | Rangovas | 40h |  |
| 164 | 4.7.18.2 | Tech. priežiūra derina/pateikia pastabas dokumentacijai |  | 7d | 2021-11-11 | 2021-11-22 | 163 | 0d |  | Litgrid AB | 56h |  |
| 165 | 4.7.18.3 | Operatyvinio personalo mokymai |  | 1d | 2021-11-23 | 2021-11-23 | 164 | 0d |  | Rangovas | 8h |  |
| 166 | 4.7.18.4 | Rangovas pateikia raštą dėl TĮK organizavimo (su tech. priežiūros vadovo parašu) |  | 1d | 2021-11-23 | 2021-11-24 | 165 | 0d |  | Rangovas | 8h |  |
| 167 | 4.7.18.5 | TĮK organizavimas |  | 7d | 2021-11-24 | 2021-12-06 | 166 | 0d |  | Litgrid AB | 56h |  |
| 168 | 4.7.18.6 | Techninio įvertinimo komisija | milestone | 0d | 2021-12-06 | 2021-12-06 | 167 | 0d |  | Rangovas; Litgrid AB |  |  |
| 169 | 4.7.18.7 | TĮK pastabų šalinimas |  | 5d | 2021-12-06 | 2021-12-13 | 168 | 0d |  | Rangovas | 40h |  |
| 170 | 4.7.18.8 | TP įjungimas; bandomoji ekspoatacija |  | 2d | 2021-12-13 | 2021-12-14 | 169 | 0d |  | Rangovas; Litgrid AB | 32h |  |
| 171 | 4.7.18.9 | TP įjungta | milestone | 0d | 2021-12-14 | 2021-12-14 | 170 | 0d |  | Rangovas; Litgrid AB |  |  |
| 172 | 4.8 | **II etapo statybos darbai** |  | 162d | 2021-12-14 | 2022-08-05 |  | 0d |  | Rangovas | 4264h | 4,984 |
| 173 | 4.8.1 | Rangovas detalizuoja darbus |  | 70d | 2021-12-14 | 2022-03-25 | 171 | 0d |  |  |  |  |
| 174 | 4.8.2 | **RAA nuostatų pateikimas II statybos etapui** |  | 35d | 2021-12-14 | 2022-02-02 |  | 29d |  |  | 280h |  |
| 175 | 4.8.2.1 | OL RAA nuostatų II rekonstrukcijos etapui skaičiavimas |  | 21d | 2021-12-14 | 2022-01-13 | 173SS | 29d | 0d | Litgrid AB | 168h |  |
| 176 | 4.8.2.2 | OL RAA nuostatų II rekonstrukcijos etapo užduočių rengimas |  | 13d | 2022-01-13 | 2022-02-01 | 175 | 29d | 0d | Litgrid AB | 104h |  |
| 177 | 4.8.2.3 | Užduočių pateikimas |  | 1d | 2022-02-01 | 2022-02-02 | 176 | 29d | 0d | Litgrid AB | 8h |  |
| 178 | 4.8.3 | **Gretimų TP RAA nuostatų pateikimas** |  | 31d | 2022-02-02 | 2022-03-21 |  | 76d |  |  | 248h |  |
| 179 | 4.8.3.1 | OL RAA nuostatų gretimose TP skaičiavimas |  | 20d | 2022-02-02 | 2022-03-03 | 177 | 76d | 0d | Litgrid AB | 160h |  |
| 180 | 4.8.3.2 | OL RAA nuostatų gretimose TP užduočių rengimas |  | 10d | 2022-03-03 | 2022-03-18 | 179 | 76d | 0d | Litgrid AB | 80h |  |
| 181 | 4.8.3.3 | Užduočių pateikimas |  | 1d | 2022-03-18 | 2022-03-21 | 180 | 76d |  | Litgrid AB | 8h |  |
| 182 | 4.8.4 | **II darbų etapo signalų sąrašai** |  | 40d | 2022-02-02 | 2022-04-01 |  | 29d |  |  | 320h |  |
| 183 | 4.8.4.1 | Suprojektuoti ir pateikti 1 peržiūrai ir derinimui XX TP; bei kitų su XX TP rekonstrukcija susijusių objektų (pagal poreikį); signalų sąrašai Litgrid AB ir ESO |  | 10d | 2022-02-02 | 2022-02-17 | 177 | 29d | 0d | Rangovas | 80h |  |
| 184 | 4.8.4.2 | Pateiktos pastabos po 1 peržiūros |  | 10d | 2022-02-17 | 2022-03-03 | 183 | 29d | 0d | Litgrid AB | 80h |  |
| 185 | 4.8.4.3 | Pakoreguoti pagal pastabas ir pateikti 2 peržiūrai ir derinimui signalų sąrašai Litgrid AB ir ESO |  | 5d | 2022-03-03 | 2022-03-10 | 184 | 29d | 0d | Rangovas | 40h |  |
| 186 | 4.8.4.4 | Pateiktos pastabos po 2 peržiūros |  | 5d | 2022-03-10 | 2022-03-18 | 185 | 29d | 0d | Litgrid AB | 40h |  |
| 187 | 4.8.4.5 | Pakoreguoti pagal pastabas ir pateikti III peržiūrai ir derinimui signalų sąrašai Litgrid AB ir ESO |  | 5d | 2022-03-18 | 2022-03-25 | 186 | 29d | 0d | Rangovas | 40h |  |
| 188 | 4.8.4.6 | II darbų etapo signalų sąrašai suderinti |  | 5d | 2022-03-25 | 2022-04-01 | 187 | 29d | 0d | Litgrid AB | 40h |  |
| 189 | 4.8.5 | Principinės objekto schemos pateikimas (OL permaitinimai ir kt. Pagal suderintą atjungimų grafiką) |  | 3d | 2021-12-14 | 2021-12-20 | 173SS | 207d | 0d | Rangovas | 24h |  |
| 190 | 4.8.6 | TSM modelio keitimas (dėl II etapo išmontuojamos dalies) |  | 3d | 2021-12-20 | 2021-12-22 | 189 | 207d |  | _ITTAD ITTC VSG DVS administratorius | 24h | 427.2 |
| 191 | 4.8.7 | RAA derinimo darbai |  | 15d | 2022-03-25 | 2022-04-15 | 173 | 0d |  | Rangovas | 120h |  |
| 192 | 4.8.8 | TSPĮ įrangos derinimo darbai |  | 15d | 2022-04-15 | 2022-05-09 | 191 | 0d |  | Rangovas | 120h |  |
| 193 | 4.8.9 | Pastotės RAA terminalų; teleinformacijos surinkimo ir perdavimo įrenginių (TSPĮ); ryšių įrangos; informacijos saugumo reikalavimų išpildymo tikrinimas su LITGRID AB. |  | 1d | 2022-05-06 | 2022-05-09 | 192FF | 113d |  | Rangovas | 8h |  |
| 194 | 4.8.10 | Teleinformacijos testavimai tarp RAA terminalų (valdiklių) ir TSPĮ |  | 1d | 2022-05-09 | 2022-05-10 | 192 | 106d | 0d | Rangovas; Litgrid AB | 16h |  |
| 195 | 4.8.11 | Ryšių; įrangos derinimo darbai |  | 15d | 2022-04-15 | 2022-05-09 | 192SS | 0d |  | Rangovas | 120h |  |
| 196 | 4.8.12 | Užsakymo pateikimas duomenų telekomunikacijų įrangos prijungimui į Litgrid AB TDPT |  | 1d | 2022-05-09 | 2022-05-10 | 195 | 0d |  | Litgrid AB | 8h |  |
| 197 | 4.8.13 | Litgrid AB TDPT įrangos parengimas/konfigūravimas naujos telekomunikacijų įrangos (IP; SDH; RRL; Šviesolaidis) prijungimui (Litgrid AB) |  | 4d | 2022-05-10 | 2022-05-16 | 196 | 0d |  | _ITTAD ITTC DPG duomenų tinklo administratorius (KR); _ITTAD ITTC TIG vyresnysis inžinierius; Litgrid AB; _ITTAD ITTC DPG duomenų tinklo administratorius (IP) | 128h | 1,708.8 |
| 198 | 4.8.14 | RAA OĮB rengimas/tvirtinimas |  | 10d | 2022-05-09 | 2022-05-23 | 192, 195 | 93d | 0d | Rangovas; Litgrid AB | 160h |  |
| 199 | 4.8.15 | Tipinių perjungimo lapelių ruošimas/tvirtinimas |  | 10d | 2022-05-23 | 2022-06-06 | 198 | 93d |  | Rangovas | 80h |  |

| ID | WBS | Task | Type | Duration | Start | Finish | Predecessors | Total slack | Free slack | Resources | Work | Cost |
| --- | --- | --- | --- | --- | --- | --- | --- | --- | --- | --- | --- | --- |
| 200 | 4.8.16 | **DVS (SCADA/EMS) parengiamieji darbai kompleksiniams bandymams (DVS realaus laiko displėjų parengimas; DVS pagrindinio/rezervinio centro konfigūravimas)** |  | 11d | 2022-04-01 | 2022-04-19 |  | 29d |  |  | 88h |  |
| 201 | 4.8.16.1 | DVS pagrindinio/rezervinio centro konfigūravimas atsižvelgiant į etapo pasikeitmus 3-5 d.d. |  | 3d | 2022-04-01 | 2022-04-06 | 188 | 29d | 0d | Litgrid AB | 24h |  |
| 202 | 4.8.16.2 | Principinės objekto schemos pateikimas; linijų; transformatorių parametrų pateikimas |  | 3d | 2022-04-06 | 2022-04-11 | 201 | 29d | 0d | Rangovas | 24h |  |
| 203 | 4.8.16.3 | DVS realaus laiko displėjų parengimas 3-5 d.d. (SVD darbai) |  | 5d | 2022-04-11 | 2022-04-19 | 201, 202 | 29d |  | Litgrid AB | 40h |  |
| 204 | 4.8.17 | TSPĮ konfigūracijos pateikimas |  | 1d | 2022-05-10 | 2022-05-11 | 194 | 106d | 0d | Rangovas | 8h |  |
| 205 | 4.8.18 | TSPĮ konfigūracijos derinimas su užsakovu (Litgrid AB) |  | 5d | 2022-05-11 | 2022-05-18 | 204 | 106d |  | Litgrid AB | 40h |  |
| 206 | 4.8.19 | II etapo įrenginių testavimas bandymai objekte ir/ar tarp skirtingų objektų (pasiruošimas kompleksiniams bandymas) |  | 10d | 2022-05-16 | 2022-05-30 | 197 | 0d |  | Rangovas | 80h |  |
| 207 | 4.8.20 | II etapo įrenginių kompleksiniai bandymai su PSO SCADA |  | 7d | 2022-05-30 | 2022-06-08 | 203, 206 | 0d |  | Rangovas; Litgrid AB | 112h |  |
| 208 | 4.8.21 | **DVS (SCADA/EMS) baigiamojo etapo darbai)** |  | 56d | 2022-04-11 | 2022-06-30 |  | 76d |  |  | 488h | 2,848 |
| 209 | 4.8.21.1 | Skaičiuojamųjų matavimų koregavimas DVS |  | 3d | 2022-06-08 | 2022-06-13 | 207 | 76d | 0d | Litgrid AB | 24h |  |
| 210 | 4.8.21.2 | DVS realaus laiko displėjų parengimo užbaigimas |  | 7d | 2022-06-13 | 2022-06-22 | 209 | 76d | 0d | Litgrid AB | 56h |  |
| 211 | 4.8.21.3 | Pateikiama rekonstrukcijos II etapo schema ir parametrai |  | 5d | 2022-06-22 | 2022-06-30 | 210 | 76d |  | Rangovas | 40h |  |
| 212 | 4.8.21.4 | TSM modelio keitimas (dėl II etapo) |  | 2d | 2022-04-11 | 2022-04-13 | 202 | 96d | 0d | Litgrid AB | 16h |  |
| 213 | 4.8.21.5 | Visos būtinos dokumentacijos įrenginių įjungimui patvirtinimas/vizavimas; Pateiktas galutinis TPL sąrašas suvedimui į DVS |  | 2d | 2022-04-13 | 2022-04-15 | 212 | 96d | 0d | Rangovas | 16h |  |
| 214 | 4.8.21.6 | Automatinių tipinių perjungimo lapelių suvedimas į PSO DVS |  | 20d | 2022-04-15 | 2022-05-16 | 213 | 96d | 0d | _ITTAD ITTC VSG DVS administratorius | 160h | 2,848 |
| 215 | 4.8.21.7 | Automatinių tipinių perjungimo lapelių testavimas realiomis sąlygomis |  | 10d | 2022-05-16 | 2022-05-30 | 214 | 96d | 0d | Rangovas; Litgrid AB | 160h |  |
| 216 | 4.8.21.8 | TDPT naujos įrangos įvedimas į monitoringo ir valdymo sistemas |  | 2d | 2022-05-30 | 2022-06-01 | 215 | 96d |  | Litgrid AB | 16h |  |
| 217 | 4.8.22 | **Techninio įvertinimo komisija (II etapo)** |  | 20d | 2022-06-08 | 2022-07-08 |  | 0d |  |  | 336h |  |
| 218 | 4.8.22.1 | Techninės dokumentacijos pateikimas Užsakovui pagal PU 5 priedą |  | 1d | 2022-06-08 | 2022-06-09 | 207 | 0d |  | Rangovas | 8h |  |
| 219 | 4.8.22.2 | Techninės dokumentacijos pateikimas ir derinimas su Užsakovu pagal PU 5 priedą |  | 5d | 2022-06-09 | 2022-06-16 | 218 | 0d |  | Litgrid AB | 192h |  |
| 220 | 4.8.22.3 | Operatyvinio personalo mokymai |  | 1d | 2022-06-16 | 2022-06-17 | 219 | 0d |  | Rangovas | 8h |  |
| 221 | 4.8.22.4 | Įjungimo programos rengimas ir derinimas |  | 5d | 2022-06-17 | 2022-06-27 | 220 | 0d |  | Rangovas | 40h |  |
| 222 | 4.8.22.5 | Techninio įvertinimo komisija (II etapo) |  | 1d | 2022-06-27 | 2022-06-28 | 221 | 0d |  | Rangovas; Litgrid AB | 16h |  |
| 223 | 4.8.22.6 | Techninio įvertinimo komisijos (II etapo) pastabų šalinimas |  | 5d | 2022-06-28 | 2022-07-05 | 222 | 0d |  | Rangovas | 40h |  |
| 224 | 4.8.22.7 | TP įjungimas; bandomoji ekspoatacija |  | 2d | 2022-07-05 | 2022-07-08 | 223 | 0d |  | Rangovas; Litgrid AB | 32h |  |
| 225 | 4.8.22.8 | TP įjungta | milestone | 0d | 2022-07-08 | 2022-07-08 | 224 | 0d |  | Rangovas; Litgrid AB |  |  |
| 226 | 4.8.23 | RAA nuostatų keitimas gretimose TP |  | 20d | 2022-07-08 | 2022-08-05 | 225, 181 | 0d |  | Rangovas | 160h |  |
| 227 | 4.8.24 | RANGOS DARBAI OBJEKTE BAIGTI | milestone | 0d | 2022-08-05 | 2022-08-05 | 226 | 0d |  |  |  |  |

Notes:
- 200: (3-5 d.d. priklauso nuo apimties, kiekvieno projekto metu derinama atskirai)
- 208: (14-30 d.d. priklauso nuo apimties, kiekvieno projekto metu derinama atskirai)
- 214: (10-20 d.d.; 50 operacijų į dieną kartu su testavimu imitatoriumi)

| ID | WBS | Task | Type | Duration | Start | Finish | Predecessors | Baseline start | Baseline finish | Baseline duration | Total slack | Resources | Work |
| --- | --- | --- | --- | --- | --- | --- | --- | --- | --- | --- | --- | --- | --- |
| 228 | 5 | **III ETAPAS. STATYBOS UŽBAIGIMO AKTAS** |  | 51d | 2022-08-05 | 2022-10-18 |  | 2022-01-19 | 2022-02-18 | 22d | 0d |  | 816h |
| 229 | 5.1 | Išpildomosios topografinės nuotraukos parengimas |  | 20d | 2022-08-05 | 2022-09-05 | 227 |  |  |  | 0d | Rangovas | 160h |
| 230 | 5.2 | **Statinių kadastrinės bylos parengimas; suderinimas ir registrų centro išankstinė patikra** |  | 18d | 2022-09-05 | 2022-09-29 |  |  |  |  | 0d | Rangovas | 288h |
| 231 | 5.2.1 | Rangovas rengia statinių kadastrinė bylą |  | 10d | 2022-09-05 | 2022-09-19 | 229 |  |  |  | 0d | Rangovas | 80h |
| 232 | 5.2.2 | Statinių kadastrinės bylos derinimas |  | 5d | 2022-09-19 | 2022-09-26 | 231 |  |  |  | 0d | Litgrid AB | 40h |
| 233 | 5.2.3 | Statinių kadastrinės bylos išankstinis suderinimas su registrų centru |  | 3d | 2022-09-26 | 2022-09-29 | 232 |  |  |  | 0d | Rangovas | 24h |
| 234 | 5.3 | **Žemės sklypo kadastrinės bylos parengimas; suderinimas ir registrų centro išankstinė patikra** |  | 18d | 2022-09-05 | 2022-09-29 |  |  |  |  | 0d |  | 144h |
| 235 | 5.3.1 | Rangovas rengia žemės sklypo kadastrinė bylą |  | 10d | 2022-09-05 | 2022-09-19 | 229 |  |  |  | 0d | Rangovas | 80h |
| 236 | 5.3.2 | Žemės sklypo kadastrinės bylos derinimas |  | 5d | 2022-09-19 | 2022-09-26 | 235 |  |  |  | 0d | Litgrid AB | 40h |
| 237 | 5.3.3 | Žemės sklypo kadastrinės bylos išankstinis suderinimas su registrų centru |  | 3d | 2022-09-26 | 2022-09-29 | 236 |  |  |  | 0d | Rangovas | 24h |
| 238 | 5.4 | **Statybos užbaigimo procedūrų organizavimas** |  | 13d | 2022-09-29 | 2022-10-18 |  | 2022-01-19 | 2022-02-15 | 20d | 0d | Rangovas | 224h |
| 239 | 5.4.1 | SUA prašymo dokumentų įkėlimas į IS Infostatyba |  | 3d | 2022-09-29 | 2022-10-04 | 233, 237 |  |  |  | 0d | Rangovas | 24h |
| 240 | 5.4.2 | Preliminaraus SUA suderinimas su Litgrid AB (atspausdintas iš IS Infostatyba) |  | 3d | 2022-10-04 | 2022-10-07 | 239 |  |  |  | 0d | Litgrid AB | 24h |
| 241 | 5.4.3 | SUA prašymo pateikimas Infostatyboje |  | 2d | 2022-10-07 | 2022-10-11 | 240 |  |  |  | 0d | Rangovas | 16h |
| 242 | 5.4.4 | Dokumentų peržiūra |  | 3d | 2022-10-11 | 2022-10-14 | 241 |  |  |  | 0d | Infostatyba | 24h |
| 243 | 5.4.5 | Galutinė statybos užbaigimo komisija |  | 2d | 2022-10-14 | 2022-10-18 | 242 | 2022-02-17 | 2022-02-18 | 2d | 0d | Infostatyba; Rangovas | 32h |
| 244 | 5.4.6 | SUA gautas/Rangos sutarties pabaiga | milestone | 0d | 2022-10-18 | 2022-10-18 | 243 |  |  |  | 0d | Rangovas |  |
